# Proyecto Implementación sistema de tea

Schedule from MS Project, 2024-09-02 to 2025-06-06, status date 2024-06-19.

## Calendars

- Estándar: Mon-Fri 09:00-13:00, 15:00-19:00; Sat-Sun off.

## Schedule

| ID | WBS | Task | Type | Duration | Start | Finish | Predecessors | Total slack | Constraint |
| --- | --- | --- | --- | --- | --- | --- | --- | --- | --- |
| 1 | 1 | **IMPLEMENTACIÓN DE UN SISTEMA DE TEA** |  | 200d | 2024-09-02 | 2025-06-06 |  | 0d |  |
| 2 | 1.1 | **Inicio del proyecto** |  | 10d | 2024-09-02 | 2024-09-13 |  | 0d |  |
| 3 | 1.1.1 | Revisión y aprobación del plan de gestión del proyecto |  | 4d | 2024-09-02 | 2024-09-05 |  | 0d | start no earlier than 2024-09-02 |
| 4 | 1.1.2 | Definición del equipo del proyecto |  | 4d | 2024-09-06 | 2024-09-11 | 3 | 0d |  |
| 5 | 1.1.3 | Asignación de roles |  | 2d | 2024-09-12 | 2024-09-13 | 4 | 0d |  |
| 6 | 1.1.4 | Kick off meeting | milestone | 0d | 2024-09-13 | 2024-09-13 | 5 | 0d |  |
| 7 | 1.2 | **Planificación detallada** |  | 20d | 2024-09-16 | 2024-10-11 |  | 0d |  |
| 8 | 1.2.1 | Planos de ingeniería y especificaciones técnicas |  | 10d | 2024-09-16 | 2024-09-27 | 6 | 0d |  |
| 9 | 1.2.2 | Definir procedimientos de adquisición y contratación de proveedores |  | 10d | 2024-09-30 | 2024-10-11 | 8 | 0d |  |
| 10 | 1.3 | **Adquisición de equipos** |  | 40d | 2024-10-14 | 2024-12-06 |  | 0d |  |
| 11 | 1.3.1 | Selección y contratación de proveedores |  | 20d | 2024-10-14 | 2024-11-08 | 9 | 0d |  |
| 12 | 1.3.2 | Compra y entrega de equipos y materiales |  | 20d | 2024-11-11 | 2024-12-06 | 11 | 0d |  |
| 13 | 1.4 | **Instalación y configuración** |  | 60d | 2024-12-09 | 2025-02-28 | 11 | 0d |  |
| 14 | 1.4.1 | Instalación sistema de tea |  | 30d | 2024-12-09 | 2025-01-17 | 12 | 0d |  |
| 15 | 1.4.2 | Instalacion componentes y accesorios |  | 20d | 2025-01-20 | 2025-02-14 | 14 | 0d |  |
| 16 | 1.4.3 | Integración con sistemad de monitoreo y control |  | 10d | 2025-02-17 | 2025-02-28 | 15 | 0d |  |
| 17 | 1.5 | **Capacitación del personal** |  | 30d | 2025-03-03 | 2025-04-11 | 16 | 0d |  |
| 18 | 1.5.1 | Desarrollo programa de capacitación |  | 15d | 2025-03-03 | 2025-03-21 | 16 | 0d |  |
| 19 | 1.5.2 | Simulacros y ejercicios de emergencias |  | 15d | 2025-03-24 | 2025-04-11 | 18 | 0d |  |
| 20 | 1.6 | **Validación y pruebas** |  | 30d | 2025-04-14 | 2025-05-23 | 19 | 0d |  |
| 21 | 1.6.1 | Desarrollar plan de calidad |  | 10d | 2025-04-14 | 2025-04-25 |  | 0d |  |
| 22 | 1.6.2 | Pre com y comisionamiento |  | 10d | 2025-04-28 | 2025-05-09 | 21 | 0d |  |
| 23 | 1.6.3 | Puesta en marcha |  | 5d | 2025-05-12 | 2025-05-16 | 22 | 0d |  |
| 24 | 1.6.4 | Ajustes finales |  | 5d | 2025-05-19 | 2025-05-23 | 23 | 0d |  |

| ID | WBS | Task | Type | Duration | Start | Finish | Predecessors | Total slack |
| --- | --- | --- | --- | --- | --- | --- | --- | --- |
| 25 | 1.7 | **Cierre del proyecto** |  | 10d | 2025-05-26 | 2025-06-06 | 23 | 0d |
| 26 | 1.7.1 | Documentación y entrega formal del proyecto |  | 10d | 2025-05-26 | 2025-06-06 | 24 | 0d |
| 27 | 2 | Fin | milestone | 0d | 2025-06-06 | 2025-06-06 | 26 | 0d |
